# CSF Upgrades and Migrations

Schedule from MS Project, 2013-01-14 to 2013-06-14, A marks actual dates.
MIT

## Calendars

- Standard: Mon-Fri 08:00-12:00, 13:00-17:00; Sat-Sun off.

## Resources

| Resource |
| --- |
| Dave |
| René |
| Steve |
| Felicia |
| Ram |
| Kevin |
| Brian |
| Janet |
| Seth |
| Lee |
| Faith |
| Peter |
| Debra |
| Frank Q. |

## Schedule

| ID | WBS | Task | Type | Duration | Start | Finish | Predecessors | Complete | Baseline start | Baseline finish | Baseline duration | Resources | Work | Actual work |
| --- | --- | --- | --- | --- | --- | --- | --- | --- | --- | --- | --- | --- | --- | --- |
| 1 | 1 | Upgrade CSF to 2.0 |  | 10d | 2013-01-14 A | 2013-01-25 A |  | 100% |  |  |  |  |  |  |
| 2 | 2 | **Upgrade of Existing CSF Apps to CSF 2.0** |  | 46d | 2013-02-13 A | 2013-04-17 A |  | 100% | 2013-02-13 | 2013-03-08 | 18d? |  | 257.6h | 257.6h |
| 3 | 2.1 | **Development** |  | 11d | 2013-02-13 A | 2013-02-27 A |  | 100% | 2013-02-13 | 2013-03-08 | 18d |  | 64h | 64h |
| 4 | 2.1.1 | Upgrade IAP |  | 7d | 2013-02-14 A | 2013-02-25 A | 1FS+13d | 100% | 2013-02-14 | 2013-02-20 | 4d | Steve [50%] | 28h | 28h |
| 5 | 2.1.2 | Upgrade Subject Evaluation Report/OSE Report |  | 1d | 2013-02-26 A | 2013-02-26 A | 4FS+3d | 100% | 2013-02-26 | 2013-03-01 | 4d | Steve [50%] | 4h | 4h |
| 6 | 2.1.3 | Upgrade Sponsor Billing |  | 4d | 2013-02-13 A | 2013-02-19 A | 1FS+12d | 100% | 2013-02-13 | 2013-02-19 | 4d | Dave [50%] | 16h | 16h |
| 7 | 2.1.4 | Upgrade Survey Engine |  | 2d | 2013-02-26 A | 2013-02-27 A | 6FS+4d | 100% | 2013-02-26 | 2013-03-01 | 4d | Dave [50%] | 8h | 8h |
| 8 | 2.1.5 | Upgrade Response Rate Report |  | 2d | 2013-02-22 A | 2013-02-25 A | 7FS+1d | 100% | 2013-03-05 | 2013-03-08 | 4d | Dave [50%] | 8h | 8h |
| 9 | 2.1.6 | Upgrades complete | milestone | 0d | 2013-02-27 A | 2013-02-27 A | 4, 5, 6, 7, 8 | 100% | 2013-03-08 | 2013-03-08 | 0d | Dave [50%]; Steve [50%] |  |  |
| 10 | 2.2 | **Testing** |  | 30d | 2013-02-20 A | 2013-04-02 A |  | 100% |  |  |  |  | 113.6h | 113.6h |
| 11 | 2.2.1 | **Test Planning** |  | 8d | 2013-02-20 A | 2013-03-01 A |  | 100% |  |  |  |  | 31.6h | 31.6h |
| 12 | 2.2.1.1 | Sponsor Billing |  | 3d | 2013-02-20 A | 2013-02-22 A | 4SS+4d | 100% |  |  |  | Seth [25%]; Faith [25%] | 7.6h | 7.6h |
| 13 | 2.2.1.2 | OSE Applications |  | 3d | 2013-02-27 A | 2013-03-01 A | 12FS+2d | 100% |  |  |  | Lee | 24h | 24h |
| 14 | 2.2.1.3 | Test Planning Complete | milestone | 0d | 2013-03-01 A | 2013-03-01 A | 12, 13 | 100% |  |  |  |  |  |  |
| 15 | 2.2.2 | **BA Testing** |  | 27d | 2013-02-25 A | 2013-04-02 A |  | 100% |  |  |  |  | 82h | 82h |
| 16 | 2.2.2.1 | Sponsor Billing |  | 3d | 2013-02-25 A | 2013-02-27 A | 12 | 100% |  |  |  | Faith [25%] | 6h | 6h |
| 17 | 2.2.2.2 | IAP (includes planning) |  | 22d | 2013-03-04 A | 2013-04-02 A | 16FS+2d | 100% |  |  |  | Seth [25%] | 44h | 44h |
| 18 | 2.2.2.3 | OSE Applications |  | 4d | 2013-03-04 A | 2013-03-07 A | 13 | 100% |  |  |  | Lee | 32h | 32h |
| 19 | 2.2.2.4 | BA Testing Complete | milestone | 0d | 2013-03-28 A | 2013-03-28 A | 16, 18, 17 | 100% |  |  |  |  |  |  |
| 20 | 2.2.3 | **UAT** |  | 4d | 2013-03-04 A | 2013-03-07 A |  | 100% |  |  |  |  |  |  |
| 21 | 2.2.3.1 | OSE Applications |  | 4d | 2013-03-04 A | 2013-03-07 A | 18SS | 100% |  |  |  |  |  |  |
| 22 | 2.2.3.2 | UAT Complete | milestone | 0d | 2013-03-07 A | 2013-03-07 A | 21 | 100% |  |  |  |  |  |  |
| 23 | 2.2.4 | Testing Efforts Complete | milestone | 0d | 2013-03-28 A | 2013-03-28 A | 14, 19, 22 | 100% |  |  |  |  |  |  |
| 24 | 2.3 | **Deployment Preparation** |  | 11d | 2013-04-03 A | 2013-04-17 A |  | 100% |  |  |  |  | 80h | 80h |
| 25 | 2.3.1 | Get business approval for IAP |  | 10d | 2013-04-03 A | 2013-04-17 A | 17 | 100% |  |  |  | Seth | 80h | 80h |

| ID | WBS | Task | Type | Duration | Start | Finish | Predecessors | Complete | Remaining | Baseline start | Baseline finish | Baseline duration | Total slack | Free slack | Constraint | Resources | Work | Actual work |
| --- | --- | --- | --- | --- | --- | --- | --- | --- | --- | --- | --- | --- | --- | --- | --- | --- | --- | --- |
| 26 | 2.4 | **Go-live** |  | 35d | 2013-02-28 A | 2013-04-17 A |  | 100% |  |  |  |  |  |  |  |  |  |  |
| 27 | 2.4.1 | Sponsor Billing |  | 1d | 2013-02-28 A | 2013-02-28 A | 16FS+2d | 100% |  |  |  |  |  |  |  |  |  |  |
| 28 | 2.4.2 | IAP | milestone | 0d | 2013-04-17 A | 2013-04-17 A | 17FS+2d, 25 | 100% |  |  |  |  |  |  |  |  |  |  |
| 29 | 2.4.3 | OSE Applications |  | 1d | 2013-03-07 A | 2013-03-08 A | 18, 21 | 100% |  |  |  |  |  |  |  |  |  |  |
| 30 | 2.5 | Upgrade of Existing CSF Apps to CSF 2.0 Complete | milestone | 0d | 2013-04-17 A | 2013-04-17 A | 27, 28, 29 | 100% |  |  |  |  |  |  |  |  |  |  |
| 31 | 3 | **Convert SAIS-Common Apps to CSF 2.0** |  | 90d? | 2013-01-14 A | 2013-05-20 |  | 56% | 39.15d? |  |  |  | 20d |  |  |  | 86.5h | 50h |
| 32 | 3.1 | **Batch Admin** |  | 41d | 2013-03-22 A | 2013-05-20 |  | 58% | 17.3d |  |  |  | 20d |  |  |  | 86.5h | 50h |
| 33 | 3.1.1 | Development |  | 23d | 2013-03-22 A | 2013-04-24 A |  | 100% |  |  |  |  |  |  |  | Steve [25%] | 46h | 46h |
| 34 | 3.1.2 | Do file comparison |  | 2d | 2013-04-25 A | 2013-04-26 A | 33 | 100% |  |  |  |  |  |  |  | Steve [25%] | 4h | 4h |
| 35 | 3.1.3 | Do SAP testing - iteration 1 |  | 5d | 2013-05-06 | 2013-05-10 | 34FS+5d |  |  |  |  |  | 20d | 0d |  | Frank Q. [25%] | 10h |  |
| 36 | 3.1.4 | Do SAP testing - iteration 2 |  | 5d | 2013-05-13 | 2013-05-17 | 35 |  |  |  |  |  | 20d |  |  | Frank Q. [25%] | 10h |  |
| 37 | 3.1.5 | **Deployment Preparation** |  | 8.25d | 2013-05-06 | 2013-05-16 |  |  |  |  |  |  | 21.75d |  |  |  | 16.5h |  |
| 38 | 3.1.5.1 | Create deployment plan |  | 7d | 2013-05-06 | 2013-05-14 | 35SS |  |  |  |  |  | 21.75d | 0d |  | René [25%] | 14h |  |
| 39 | 3.1.5.2 | Review deployment plan with participants |  | 0.25d | 2013-05-15 | 2013-05-15 | 38 |  |  |  |  |  | 21.75d | 0d |  | René [25%] | 0.5h |  |
| 40 | 3.1.5.3 | Get business approval |  | 1d | 2013-05-15 | 2013-05-16 | 39 |  |  |  |  |  | 21.75d | 1.75d |  | René [25%] | 2h |  |
| 41 | 3.1.6 | Go-live | milestone | 0d | 2013-05-20 | 2013-05-20 | 40, 34 |  |  |  |  |  | 20d |  | start no earlier than 2013-05-20 |  |  |  |
| 42 | 3.2 | Bundle 1 (Advisor Assignment, Instructor Assignment, Supervisor Assignment, and Reg Control List) |  | 1d? | 2013-01-14 | 2013-01-14 |  |  |  |  |  |  | 109d |  |  |  |  |  |
| 43 | 4 | **PE REG Upgrade** |  | 73d? | 2013-01-14 A | 2013-04-24 |  | 80% | 14.93d? | 2013-02-07 | 2013-03-07 | 21d? | 37d |  |  |  | 410h | 298h |
| 44 | 4.1 | **Phase I - Java 6, Touchstone, and CSF Enabling** |  | 55d? | 2013-02-07 A | 2013-04-24 |  | 97% | 1.53d? | 2013-02-07 | 2013-03-07 | 21d? | 37d |  |  |  | 306h | 298h |
| 45 | 4.1.1 | **Development** |  | 27d | 2013-02-07 A | 2013-03-15 A |  | 100% |  | 2013-02-07 | 2013-03-07 | 21d |  |  |  |  | 208h | 208h |
| 46 | 4.1.1.1 | Do set-up and configuration required for upgrade |  | 5d | 2013-02-07 A | 2013-02-13 A |  | 100% |  | 2013-02-07 | 2013-02-13 | 5d |  |  |  | Ram | 40h | 40h |
| 47 | 4.1.1.2 | Perform upgrade |  | 9d | 2013-02-14 A | 2013-02-27 A | 46 | 100% |  | 2013-02-14 | 2013-02-21 | 5d |  |  |  | Ram | 72h | 72h |
| 48 | 4.1.1.3 | Unit test changes |  | 12d | 2013-02-28 A | 2013-03-15 A | 47 | 100% |  | 2013-02-22 | 2013-03-07 | 10d |  |  |  | Ram | 96h | 96h |
| 49 | 4.1.2 | **Testing** |  | 45d | 2013-02-20 A | 2013-04-23 A |  | 100% |  |  |  |  |  |  |  |  | 58h | 58h |
| 50 | 4.1.2.1 | Test planning |  | 12d | 2013-02-20 A | 2013-03-07 A | 47SS+4d | 100% |  |  |  |  |  |  |  | Debra [25%] | 24h | 24h |
| 51 | 4.1.2.2 | QA testing |  | 12d | 2013-03-18 A | 2013-04-02 A | 50, 48 | 100% |  |  |  |  |  |  |  | Debra [25%] | 24h | 24h |
| 52 | 4.1.2.3 | Load testing |  | 5d | 2013-04-04 A | 2013-04-10 A | 51FS+1d | 100% |  |  |  |  |  |  |  | Steve [25%] | 10h | 10h |
| 53 | 4.1.2.4 | User testing |  | 11d | 2013-04-09 A | 2013-04-23 A | 51FS+4d | 100% |  |  |  |  |  |  |  |  |  |  |

| ID | WBS | Task | Type | Duration | Start | Finish | Predecessors | Complete | Remaining | Baseline start | Baseline finish | Baseline duration | Total slack | Free slack | Constraint | Resources | Work | Actual work |
| --- | --- | --- | --- | --- | --- | --- | --- | --- | --- | --- | --- | --- | --- | --- | --- | --- | --- | --- |
| 54 | 4.1.3 | **Deployment Preparation** |  | 5d? | 2013-04-16 A | 2013-04-22 |  | 80% | 1d? |  |  |  | 38d |  |  |  | 40h | 32h |
| 55 | 4.1.3.1 | Create deployment plan |  | 4d | 2013-04-16 A | 2013-04-19 A | 53SS | 100% |  |  |  |  |  |  |  | René | 32h | 32h |
| 56 | 4.1.3.2 | Review deployment plan with participants |  | 1d? | 2013-04-22 | 2013-04-22 | 55 |  |  |  |  |  | 38d | 1d |  | René | 8h |  |
| 57 | 4.1.4 | Go-live |  | 1d | 2013-04-24 | 2013-04-24 | 53, 56 |  |  |  |  |  | 37d |  |  |  |  |  |
| 58 | 4.2 | **Phase II - Full CSF Upgrade** |  | 47d? | 2013-01-14 | 2013-03-19 |  |  |  |  |  |  | 63d |  |  |  | 104h |  |
| 59 | 4.2.1 | **Development** |  | 2d? | 2013-03-18 | 2013-03-19 |  |  |  |  |  |  | 63d |  |  |  | 16h |  |
| 60 | 4.2.1.1 | Perform full upgrade |  | 1d? | 2013-03-18 | 2013-03-18 | 48 |  |  |  |  |  | 63d | 0d |  | Ram | 8h |  |
| 61 | 4.2.1.2 | Unit test changes |  | 1d? | 2013-03-19 | 2013-03-19 | 60 |  |  |  |  |  | 63d |  |  | Ram | 8h |  |
| 62 | 4.2.2 | **Testing** |  | 1d? | 2013-01-14 | 2013-01-14 |  |  |  |  |  |  | 109d |  |  |  |  |  |
| 63 | 4.2.2.1 | QA |  | 1d? | 2013-01-14 | 2013-01-14 |  |  |  |  |  |  | 109d |  |  |  |  |  |
| 64 | 4.2.2.2 | User |  | 1d? | 2013-01-14 | 2013-01-14 |  |  |  |  |  |  | 109d | 11d |  |  |  |  |
| 65 | 4.2.3 | **Deployment Preparation** |  | 12d | 2013-01-14 | 2013-01-29 |  |  |  |  |  |  | 98d |  |  |  | 88h |  |
| 66 | 4.2.3.1 | Create deployment plan |  | 10d | 2013-01-14 | 2013-01-28 |  |  |  |  |  |  | 98d | 0d |  | René | 80h |  |
| 67 | 4.2.3.2 | Review deployment plan with participants |  | 1d | 2013-01-29 | 2013-01-29 | 66 |  |  |  |  |  | 98d | 0d |  | René | 8h |  |
| 68 | 4.2.4 | Go-live |  | 1d? | 2013-01-14 | 2013-01-14 |  |  |  |  |  |  | 109d |  |  |  |  |  |
| 69 | 4.3 | PE REG upgrade complete | milestone | 0d | 2013-01-29 | 2013-01-29 | 64, 67 |  |  |  |  |  | 98d |  |  | Ram |  |  |
| 70 | 5 | **OREG to Conversion to CSF 2.0** |  | 90d | 2013-02-11 A | 2013-06-14 |  | 62% | 34.36d | 2013-02-11 | 2013-05-28 | 76d | 0d |  |  |  | 790h | 526h |
| 71 | 5.1 | **Development (including unit testing)** |  | 37d | 2013-02-11 A | 2013-04-02 A |  | 100% |  | 2013-02-11 | 2013-03-22 | 29d |  |  |  |  | 400h | 400h |
| 72 | 5.1.1 | Phase 1 - Required as-is , high priority (A/D and OREG) |  | 9d | 2013-02-11 A | 2013-02-22 A |  | 100% |  |  |  |  |  |  | start no earlier than 2013-02-11 | Felicia | 72h | 72h |
| 73 | 5.1.2 | Phase 2 - Medium priority validation and messaging |  | 18d | 2013-02-25 A | 2013-03-20 A | 72 | 100% |  |  |  |  |  |  |  | Felicia | 144h | 144h |
| 74 | 5.1.3 | Phase 3 - Stabilize JAR and rafactor CSF dependencies |  | 8d | 2013-03-13 A | 2013-03-22 A | 73FS-6d | 100% |  |  |  |  |  |  |  | Felicia | 64h | 64h |
| 75 | 5.1.4 | Phase 4 - Modify OREG to use new JAR and upgrade to CSF 2.0 |  | 15d | 2013-03-13 A | 2013-04-02 A | 74SS | 100% |  |  |  |  |  |  |  | Felicia | 120h | 120h |
| 76 | 5.1.5 | OREG conversion development complete | milestone | 0d | 2013-04-02 A | 2013-04-02 A | 75 | 100% |  |  |  |  |  |  |  | Felicia |  |  |
| 77 | 5.2 | Regression Testing |  | 24d | 2013-04-01 A | 2013-05-03 | 76FS-2d | 63% | 9d | 2013-03-25 | 2013-04-26 | 24d | 21d | 0d |  | Kevin | 192h | 120h |
| 78 | 5.3 | UAT |  | 15d | 2013-04-29 A | 2013-05-17 | 77FS-5d | 20% | 12d | 2013-04-29 | 2013-05-24 | 20d | 18d | 0d |  | Peter [25%] | 30h | 6h |

| ID | WBS | Task | Type | Duration | Start | Finish | Predecessors | Complete | Remaining | Baseline start | Baseline finish | Baseline duration | Total slack | Free slack | Constraint | Resources | Work | Actual work |
| --- | --- | --- | --- | --- | --- | --- | --- | --- | --- | --- | --- | --- | --- | --- | --- | --- | --- | --- |
| 79 | 5.4 | **Deployment Preparation** |  | 11d | 2013-04-29 | 2013-05-13 |  |  |  |  |  |  | 24d |  |  |  | 88h |  |
| 80 | 5.4.1 | Create deployment plan |  | 5d | 2013-04-29 | 2013-05-03 | 78SS |  |  |  |  |  | 24d | 0d |  | René | 40h |  |
| 81 | 5.4.2 | Review deployment plan with participants |  | 1d | 2013-05-06 | 2013-05-06 | 80 |  |  |  |  |  | 24d | 0d |  | René | 8h |  |
| 82 | 5.4.3 | Create registration support plan |  | 5d | 2013-05-07 | 2013-05-13 | 81 |  |  |  |  |  | 24d |  |  | René | 40h |  |
| 83 | 5.5 | Go-live | milestone | 0d | 2013-05-21 | 2013-05-21 | 78FS+2d |  |  | 2013-05-28 | 2013-05-28 | 0d | 18d | 0d |  | René |  |  |
| 84 | 5.6 | Prod smoke test | milestone | 0d | 2013-05-21 | 2013-05-21 | 83 |  |  |  |  |  | 18d |  |  | Peter |  |  |
| 85 | 5.7 | Registration opens | milestone | 0d | 2013-06-03 | 2013-06-03 |  |  |  |  |  |  | 0d |  | start no earlier than 2013-06-03 | Peter |  |  |
| 86 | 5.8 | Registration support |  | 10d | 2013-06-03 | 2013-06-14 | 85 |  |  |  |  |  | 0d |  |  | René | 80h |  |
| 87 | 6 | **Notes Utility Beta** |  | 80d | 2013-02-25 A | 2013-06-14 |  | 53% | 37.59d |  |  |  | 0d |  |  |  | 602h | 346h |
| 88 | 6.1 | **Functional Specs** |  | 26.25d | 2013-02-25 A | 2013-04-02 A |  | 100% |  |  |  |  |  |  |  |  | 178h | 178h |
| 89 | 6.1.1 | Write functional specs |  | 17d | 2013-02-25 A | 2013-03-19 A |  | 100% |  |  |  |  |  |  |  | Seth | 136h | 136h |
| 90 | 6.1.2 | Have team review of functional specs |  | 0.25d | 2013-03-22 A | 2013-03-22 A | 89FS+2d | 100% |  |  |  |  |  |  |  | Seth | 2h | 2h |
| 91 | 6.1.3 | Get sponsor approval on functional spec |  | 5d | 2013-03-26 A | 2013-04-02 A | 90FS+2d | 100% |  |  |  |  |  |  |  | René | 40h | 40h |
| 92 | 6.1.4 | Functional specs complete | milestone | 0d | 2013-04-02 A | 2013-04-02 A | 91 | 100% |  |  |  |  |  |  |  | Seth |  |  |
| 93 | 6.2 | Development |  | 28d | 2013-04-03 A | 2013-05-13 | 71, 92 | 71% | 8d |  |  |  | 24d |  |  | Felicia | 224h | 160h |
| 94 | 6.3 | IS&T validate notes |  | 1d | 2013-04-29 A | 2013-04-29 A | 93 | 100% |  |  |  |  |  |  |  | René [25%] | 2h | 2h |
| 95 | 6.4 | UAT |  | 15d | 2013-04-29 A | 2013-05-17 | 94SS | 20% | 12d |  |  |  | 18d | 0d |  | Peter [25%] | 30h | 6h |
| 96 | 6.5 | **Deployment Preparation** |  | 11d | 2013-04-29 | 2013-05-13 |  |  |  |  |  |  | 24d |  |  |  | 88h |  |
| 97 | 6.5.1 | Create deployment plan |  | 5d | 2013-04-29 | 2013-05-03 | 80SS |  |  |  |  |  | 24d | 0d |  | René | 40h |  |
| 98 | 6.5.2 | Review deployment plan with participants |  | 1d | 2013-05-06 | 2013-05-06 | 97 |  |  |  |  |  | 24d | 0d |  | René | 8h |  |
| 99 | 6.5.3 | Create registration support plan |  | 5d | 2013-05-07 | 2013-05-13 | 98 |  |  |  |  |  | 24d |  |  | René | 40h |  |
| 100 | 6.6 | Go-live | milestone | 0d | 2013-05-21 | 2013-05-21 | 95FS+2d |  |  |  |  |  | 18d | 0d |  | René |  |  |
| 101 | 6.7 | Prod smoke test | milestone | 0d | 2013-05-21 | 2013-05-21 | 100 |  |  |  |  |  | 18d |  |  | Peter |  |  |
| 102 | 6.8 | Registration opens | milestone | 0d | 2013-06-03 | 2013-06-03 |  |  |  |  |  |  | 0d |  | start no earlier than 2013-06-03 | Peter |  |  |
| 103 | 6.9 | Registration support |  | 10d | 2013-06-03 | 2013-06-14 | 102 |  |  |  |  |  | 0d |  |  | René | 80h |  |

Notes:
- 94: Make sure a non-author can't access notes by manually entering in page(s) notes appear on (Subject Selection and Summary)
